# MBARI Revised Schedule

Schedule from MS Project, 2003-01-02 to 2003-07-30, status date 2003-01-14, A marks actual dates.
Tech Associates, LLC

## Calendars

- Standard: Mon-Fri 08:00-12:00, 13:00-17:00; Sat-Sun off. Exceptions (off unless hours are given): 2002-12-31 to 2003-01-02.

## Schedule

| ID | WBS | Task | Type | Duration | Start | Finish | Predecessors | Complete | Remaining | Total slack | Free slack | Constraint |
| --- | --- | --- | --- | --- | --- | --- | --- | --- | --- | --- | --- | --- |
| 1 | 1 | **ASIC Chip Design & Validation** |  | 100d | 2003-01-03 A | 2003-05-22 |  | 8% | 92d | 0d |  |  |
| 2 | 1.1 | Troubleshooting & Simulation |  | 40d | 2003-01-03 A | 2003-02-27 |  | 20% | 32d | 0d |  |  |
| 3 | 1.2 | Revalidation |  | 10d | 2003-02-28 | 2003-03-13 | 2 |  |  | 0d |  | start no earlier than 2002-07-01 |
| 4 | 1.3 | Relayout |  | 8d | 2003-03-14 | 2003-03-25 | 3 |  |  | 0d |  | start no earlier than 2002-07-23 |
| 5 | 1.4 | ASIC Wafer Manufacture |  | 30d | 2003-03-26 | 2003-05-06 | 4 |  |  | 0d |  |  |
| 6 | 1.5 | ASIC Chip Packaging |  | 8d | 2003-05-07 | 2003-05-16 | 5 |  |  | 0d |  | start no earlier than 2002-10-21 |
| 7 | 1.6 | Serialize, Ship to Reson |  | 4d | 2003-05-19 | 2003-05-22 | 6 |  |  | 0d |  | start no earlier than 2002-11-12 |
| 8 | 2 | **Receiver Card Production** |  | 20d | 2003-05-22 | 2003-06-19 |  |  |  | 0d |  |  |
| 9 | 2.1 | Receive Corrected ASIC Chips | milestone | 0d | 2003-05-22 | 2003-05-22 | 7 |  |  | 0d |  | start no earlier than 2002-11-05 |
| 10 | 2.2 | Incoming Inspection & Sort |  | 5d | 2003-05-23 | 2003-05-29 | 9 |  |  | 0d |  |  |
| 11 | 2.3 | In-House Prototype Card Build 6 |  | 1d | 2003-05-28 | 2003-05-28 | 10FS-2d |  |  | 0d |  | finish no earlier than 2002-11-18 |
| 12 | 2.4 | Pressure Test at MariPro |  | 2d | 2003-05-29 | 2003-05-30 | 11 |  |  | 0d |  | start no earlier than 2002-11-18 |
| 13 | 2.5 | ASIC Verification/Acceptance Complete | milestone | 0d | 2003-05-30 | 2003-05-30 | 12 |  |  | 0d |  |  |
| 14 | 2.6 | Test Lot Rcvr Card Build |  | 7d | 2003-06-02 | 2003-06-10 | 13 |  |  | 0d |  |  |
| 15 | 2.7 | Burn-In and Cycle Test |  | 5d | 2003-06-11 | 2003-06-17 | 14 |  |  | 0d |  |  |
| 16 | 2.8 | Pressure Test |  | 2d | 2003-06-18 | 2003-06-19 | 15 |  |  | 0d |  |  |
| 17 | 3 | **Transducer Production** |  | 22d | 2003-01-03 A | 2003-02-03 A |  | 100% |  |  |  |  |
| 18 | 3.1 | EM7204 Receiver Subassembly |  | 22d | 2003-01-03 A | 2003-02-03 A |  | 100% |  |  |  |  |
| 19 | 4 | **Receiver Unit Assembly/Test** |  | 9d | 2003-06-20 | 2003-07-02 |  |  |  | 0d |  |  |
| 20 | 4.1 | Rcvr Unit 1 Assembly |  | 2d | 2003-06-20 | 2003-06-23 | 16 |  |  | 0d |  |  |
| 21 | 4.2 | Unit 1 Burn-In Test |  | 5d | 2003-06-24 | 2003-06-30 | 20 |  |  | 0d |  |  |
| 22 | 4.3 | Unit 1 Acoustic Test |  | 1d | 2003-07-01 | 2003-07-01 | 21 |  |  | 0d |  |  |
| 23 | 4.4 | Unit 1 Pressure Test |  | 1d | 2003-07-02 | 2003-07-02 | 22 |  |  | 0d |  |  |
| 24 | 5 | **ICPU Development** |  | 80d | 2003-01-02 A | 2003-04-24 |  | 47% | 42.74d | 49d |  |  |
| 25 | 5.1 | Complete PC Board Development |  | 60d | 2003-01-02 A | 2003-03-27 |  | 50% | 30d | 49d | 0d | finish no earlier than 2002-12-31 |
| 26 | 5.2 | ICPU Integration |  | 20d | 2003-03-28 | 2003-04-24 | 25, 27 |  |  | 49d |  | finish no earlier than 2003-01-15 |
| 27 | 5.3 | 6046 Software Update |  | 15d | 2003-01-03 A | 2003-01-23 |  | 95% | 0.75d | 94d | 45d |  |

| ID | WBS | Task | Type | Duration | Start | Finish | Predecessors | Complete | Remaining | Total slack | Free slack | Constraint |
| --- | --- | --- | --- | --- | --- | --- | --- | --- | --- | --- | --- | --- |
| 28 | 6 | **Beamformer & 7-P Development** |  | 63d | 2003-01-02 A | 2003-04-01 |  | 50% | 31.5d | 86d |  |  |
| 29 | 6.1 | VHDL Programming |  | 63d | 2003-01-02 A | 2003-04-01 |  | 50% | 31.5d | 86d |  | finish no earlier than 2003-03-21 |
| 30 | 6.2 | PC Board Fabrication |  | 63d | 2003-01-02 A | 2003-04-01 |  | 50% | 31.5d | 86d |  |  |
| 31 | 7 | **Updated 7-P Delivery** |  | 32d | 2003-03-13 | 2003-04-25 |  |  |  | 68d |  |  |
| 32 | 7.1 | Receive Chasses | milestone | 0d | 2003-03-13 | 2003-03-13 |  |  |  | 68d | 0d | start no earlier than 2003-03-13 |
| 33 | 7.2 | Integrate and Test |  | 32d | 2003-03-13 | 2003-04-25 | 32 |  |  | 68d |  |  |
| 34 | 8 | **System Integration** |  | 20d | 2003-07-03 | 2003-07-30 | 23 |  |  | 0d |  |  |
| 35 | 8.1 | Unit 1 Integration |  | 20d | 2003-07-03 | 2003-07-30 | 23, 26 |  |  | 0d |  | finish no earlier than 2003-02-27 |
| 36 | 8.2 | Delivery | milestone | 0d | 2003-07-30 | 2003-07-30 | 35 |  |  | 0d |  |  |
